# Solution Decision Phase Gantt Chart

Schedule from MS Project, 2009-02-01 to 2009-04-24.
Project Perfect

## Calendars

- Standard: Mon-Fri 08:00-12:00, 13:00-17:00; Sat-Sun off.

## Schedule

| ID | WBS | Task | Type | Duration | Start | Finish | Predecessors | Total slack | Free slack |
| --- | --- | --- | --- | --- | --- | --- | --- | --- | --- |
| 1 | 1 | NOTE: All time estimates are duration rather than work. They will have to be scaled up or down to suit the project. | milestone | 0d | 2009-02-01 | 2009-02-01 |  | 20.6d |  |
| 4 | 2 | **Phase Planning** |  | 2.3d | 2009-02-02 | 2009-02-04 |  | 56.8d |  |
| 5 | 2.1 | Review the draft plan and look for changes |  | 0.2d | 2009-02-02 | 2009-02-02 |  | 56.8d | 0d |
| 6 | 2.2 | Prepare a schedule (Gantt Chart) |  | 0.2d | 2009-02-02 | 2009-02-02 | 5 | 56.8d | 0d |
| 7 | 2.3 | Allocate resources |  | 0.2d | 2009-02-02 | 2009-02-02 | 6 | 56.8d | 0d |
| 8 | 2.4 | Confirm resource availability |  | 0.5d | 2009-02-02 | 2009-02-03 | 7 | 56.8d | 0d |
| 9 | 2.5 | Revise list of issues and risks |  | 0.2d | 2009-02-03 | 2009-02-03 | 8 | 56.8d | 0d |
| 10 | 2.6 | Gain agreement to proceed |  | 1d | 2009-02-03 | 2009-02-04 | 9 | 56.8d | 0d |
| 11 | 2.7 | Planning complete | milestone | 0d | 2009-02-04 | 2009-02-04 | 10 | 56.8d |  |
| 12 | 3 | **Kick Off Meeting** |  | 2.2d | 2009-02-02 | 2009-02-04 |  | 0d |  |
| 13 | 3.1 | Schedule meeting |  | 2d | 2009-02-02 | 2009-02-03 |  | 0d |  |
| 14 | 3.2 | Prepare material |  | 1d | 2009-02-02 | 2009-02-02 |  | 1d |  |
| 15 | 3.3 | Hold meeting |  | 0.2d | 2009-02-04 | 2009-02-04 | 13, 14 | 0d |  |
| 16 | 3.4 | Kick Off meeting complete | milestone | 0d | 2009-02-04 | 2009-02-04 | 15 | 0d |  |
| 17 | 4 | **Trial** |  | 25d | 2009-02-04 | 2009-03-11 | 16 | 0d |  |
| 18 | 4.1 | Arrange trial with Vendors |  | 15d | 2009-02-04 | 2009-02-25 |  | 0d |  |
| 19 | 4.2 | Schedule resources |  | 15d | 2009-02-04 | 2009-02-25 |  | 0d |  |
| 20 | 4.3 | Prepare trial documents |  | 10d | 2009-02-04 | 2009-02-18 |  | 5d |  |
| 21 | 4.4 | Carry out Business Trial |  | 5d | 2009-02-25 | 2009-03-04 | 20, 18, 19 | 0d |  |
| 22 | 4.5 | Carry out Technology Trial |  | 5d | 2009-03-04 | 2009-03-11 | 21 | 1d | 0d |
| 23 | 4.6 | Trial Complete | milestone | 0d | 2009-03-11 | 2009-03-11 | 22, 21 | 1d | 0d |
| 24 | 5 | **Solution Impacts** |  | 5d | 2009-03-11 | 2009-03-18 | 23 | 1d |  |
| 25 | 5.1 | Review final requirements |  | 5d | 2009-03-11 | 2009-03-18 |  | 1d | 0d |
| 26 | 5.2 | Prepare gap analysis |  | 5d | 2009-03-11 | 2009-03-18 |  | 1d | 0d |
| 27 | 5.3 | Identify infrastructure requirements |  | 5d | 2009-03-11 | 2009-03-18 |  | 1d | 0d |
| 28 | 5.4 | Create implementation activity list |  | 5d | 2009-03-11 | 2009-03-18 |  | 1d | 0d |
| 29 | 5.5 | Vendor Details complete | milestone | 0d | 2009-03-18 | 2009-03-18 | 25, 28, 26, 27 | 1d |  |

| ID | WBS | Task | Type | Duration | Start | Finish | Predecessors | Total slack |
| --- | --- | --- | --- | --- | --- | --- | --- | --- |
| 30 | 6 | **References** |  | 11d | 2009-03-04 | 2009-03-19 | 21, 29 | 0d |
| 31 | 6.1 | Vendor arrange reference checks |  | 5d | 2009-03-04 | 2009-03-11 |  | 0d |
| 32 | 6.2 | Prepare reference checklist |  | 2d | 2009-03-04 | 2009-03-06 |  | 3d |
| 33 | 6.3 | Carry out reference checks |  | 5d | 2009-03-11 | 2009-03-18 | 32, 31 | 0d |
| 34 | 6.4 | Consolidate reference information |  | 1d | 2009-03-18 | 2009-03-19 | 33 | 0d |
| 35 | 6.5 | Reference checks complete | milestone | 0d | 2009-03-19 | 2009-03-19 | 34 | 0d |
| 36 | 7 | **Business Case** |  | 10d | 2009-03-19 | 2009-04-02 | 29, 35 | 0d |
| 37 | 7.1 | Identify options |  | 2d | 2009-03-19 | 2009-03-23 |  | 0d |
| 38 | 7.2 | Prepare final business case |  | 3d | 2009-03-23 | 2009-03-26 | 37 | 0d |
| 39 | 7.3 | Approve business case |  | 5d | 2009-03-26 | 2009-04-02 | 38 | 0d |
| 40 | 7.4 | Business case approved | milestone | 0d | 2009-04-02 | 2009-04-02 | 39 | 0d |
| 41 | 8 | **Purchase** |  | 10d | 2009-04-02 | 2009-04-16 | 40 | 0d |
| 42 | 8.1 | Negotiate final price |  | 5d | 2009-04-02 | 2009-04-09 |  | 3d |
| 43 | 8.2 | Review contract |  | 8d | 2009-04-02 | 2009-04-14 |  | 0d |
| 44 | 8.3 | Finalise contract |  | 2d | 2009-04-14 | 2009-04-16 | 42, 43 | 0d |
| 45 | 8.4 | Contract signed | milestone | 0d | 2009-04-16 | 2009-04-16 | 44 | 0d |
| 46 | 9 | **Report** |  | 4d | 2009-04-16 | 2009-04-22 | 45 | 0d |
| 47 | 9.1 | Produce report |  | 2d | 2009-04-16 | 2009-04-20 |  | 0d |
| 48 | 9.2 | Carry out QA |  | 0.5d | 2009-04-20 | 2009-04-20 | 47 | 0d |
| 49 | 9.3 | Carry out rework |  | 1d | 2009-04-20 | 2009-04-21 | 48 | 0d |
| 50 | 9.4 | Present report |  | 0.5d | 2009-04-21 | 2009-04-22 | 49 | 0d |
| 51 | 9.5 | Report complete | milestone | 0d | 2009-04-22 | 2009-04-22 | 50 | 0d |
| 52 | 10 | **Closure** |  | 1.9d | 2009-04-22 | 2009-04-24 | 51 | 0d |
| 53 | 10.1 | Produce plan for next phase |  | 0.4d | 2009-04-22 | 2009-04-22 |  | 0d |
| 54 | 10.2 | Agree plan with the Sponsor |  | 1d | 2009-04-22 | 2009-04-23 | 53 | 0d |
| 55 | 10.3 | Agree to proceed through the gate to the next phase |  | 0.5d | 2009-04-23 | 2009-04-24 | 54 | 0d |
| 56 | 10.4 | Phase complete | milestone | 0d | 2009-04-24 | 2009-04-24 | 55 | 0d |
